Schedule from MS Project, 2013-07-01 to 2014-03-05, A marks actual dates.
SLAC National Accelerator Laboratory

## Calendars

- Standard: Mon-Fri 08:00-12:00, 13:00-17:00; Sat-Sun off.

## Resources

| Resource |
| --- |
| Sho |
| Pelle |
| Matt |
| INFN/Orsay |
| Jlab batch |
| Jeremy |
| Maurik |
| Stacy |
| muon guys |
| Omar |
| Takashi |
| Homer |
| Norman |
| Andrea |
| Yuri/Keith |
| Kyle |
| Sarah |

## Schedule

| ID | WBS | Task | Type | Duration | Start | Finish | Predecessors | Complete | Remaining | Total slack | Free slack | Constraint | Resources | Work | Actual work |
| --- | --- | --- | --- | --- | --- | --- | --- | --- | --- | --- | --- | --- | --- | --- | --- |
| 1 | 1 | mock data challenge | milestone | 1d? | 2013-11-01 | 2013-11-04 | 52, 51, 6, 12, 11, 22 |  |  | 86.75d |  |  |  |  |  |
| 2 | 2 | **run simulation production** |  | 60d | 2013-11-20 | 2014-02-12 | 51, 55 |  |  | 15d |  |  |  | 480h |  |
| 3 | 2.1 | run SLIC |  | 2mo | 2013-11-20 | 2014-01-15 | 6, 9 |  |  | 35d |  |  | Jlab batch | 320h |  |
| 4 | 2.2 | run readout sim |  | 1mo | 2014-01-15 | 2014-02-12 | 6, 9, 17 |  |  | 15d |  |  | Jlab batch | 160h |  |
| 5 | 3 | ready to run | milestone | 0d | 2014-03-05 | 2014-03-05 | 38, 47, 50, 56 |  |  | 0d |  |  |  |  |  |
| 6 | 4 | **primary event generation** |  | 39.25d | 2013-07-01 A | 2013-08-23 |  | 49% | 20.13d | 98d | 50.25d |  |  | 120h | 40h |
| 7 | 4.1 | tune preselection cuts for trigger events |  | 2w | 2013-07-01 | 2013-08-23 |  |  |  | 98d |  |  | Takashi | 80h |  |
| 8 | 4.2 | apply multiple scattering to tridents | manual | 1.9w | 2013-07-01 A | 2013-07-12 A |  | 100% |  |  |  |  | Sho | 40h | 40h |
| 9 | 5 | **detector geometry & sim** |  | 102.25d | 2013-07-01 A | 2013-11-20 |  | 15% | 87.42d | 35d | 0d |  |  | 296h | 40h |
| 10 | 5.1 | add muon geometry |  | 2w | 2013-08-01 | 2013-09-25 |  |  |  | 31d | 0.75d |  | Maurik | 80h |  |
| 11 | 5.2 | finalize Ecal geometry (simple flange model) | manual | 1.9w | 2013-07-29 A | 2013-08-09 A |  | 100% |  |  |  | start no earlier than 2013-07-29 | Sho | 40h | 40h |
| 12 | 5.3 | finalize SVT geometry (add dead material) |  | 1.9w | 2013-08-28 | 2013-09-10 |  |  |  | 85.25d | 38d | start no earlier than 2013-08-28 | Sho | 40h |  |
| 13 | 5.4 | add beamline dead material (dipole) |  | 1w | 2013-07-29 | 2013-08-23 |  |  |  | 98d |  |  | Norman | 40h |  |
| 14 | 5.5 | compare old and current Geant4 versions |  | 1w | 2013-10-24 | 2013-11-20 |  |  |  | 35d |  |  | Maurik | 40h |  |
| 15 | 5.6 | test 3D field map in SLIC |  | 3.85w | 2013-07-01 | 2013-07-26 |  |  |  | 118d |  |  | Norman | 40h |  |
| 16 | 5.7 | add real 3D field map |  | 7.25d | 2013-09-02 | 2013-09-11 |  |  |  | 85d |  | start no earlier than 2013-09-02 | Norman | 16h |  |
| 17 | 6 | **trigger and readout sim** |  | 60.5d | 2013-09-26 | 2013-12-19 |  |  |  | 15d | 0d |  |  | 320h |  |
| 18 | 6.1 | add muon readout |  | 1w | 2013-09-26 | 2013-10-23 | 10 |  |  | 31d | 0d |  | Maurik | 40h |  |
| 19 | 6.2 | muon system trigger studies |  | 1mo | 2013-10-23 | 2013-11-20 | 18 |  |  | 31.25d | 0d |  | muon guys | 160h |  |
| 20 | 6.3 | add muon trigger |  | 1w | 2013-11-20 | 2013-11-27 | 19 |  |  | 31.25d |  |  | muon guys | 40h |  |
| 21 | 6.4 | update to reflect FADC/trigger firmware changes |  | 1.9w | 2013-12-06 | 2013-12-19 |  |  |  | 15d |  | start no earlier than 2013-12-06 | Sho | 40h |  |
| 22 | 6.5 | add noise/resolution to Ecal sim |  | 1.9w | 2013-10-21 | 2013-11-01 |  |  |  | 49d | 0d | start no earlier than 2013-10-21 | Sho | 40h |  |
| 23 | 7 | reconstruction ready | milestone | 0d | 2014-01-22 | 2014-01-22 | 24, 52 |  |  | 30d |  |  |  |  |  |
| 24 | 8 | **reconstruction** |  | 147.25d | 2013-07-01 A | 2014-01-22 |  | 30% | 102.35d | 20d | 0d |  |  | 920h | 160h |
| 25 | 8.1 | **SVT recon (tracking) improvements** |  | 147.25d | 2013-07-01 A | 2014-01-22 |  | 42% | 84.92d | 20d |  |  |  | 520h | 160h |
| 26 | 8.1.1 | vertexing in B-field |  | 1w | 2013-10-21 | 2013-11-15 |  |  |  | 68d |  |  | Norman | 40h |  |
| 27 | 8.1.2 | reorganize tracking code |  | 2w | 2013-08-26 | 2013-11-27 |  |  |  | 60d |  |  | Norman | 80h |  |
| 28 | 8.1.3 | use single layers for tracking |  | 7.85w | 2013-11-28 | 2014-01-22 |  |  |  | 20d |  | start no earlier than 2013-11-28 | Norman | 80h |  |
| 29 | 8.1.4 | kalman filter/GBL | manual | 2.73mo | 2013-07-01 A | 2013-09-13 A |  | 100% |  |  |  |  | Pelle | 160h | 160h |
| 30 | 8.1.5 | complete SVT time recon (arbitrary shape, multiple hits) |  | 3w | 2013-08-26 | 2013-10-18 |  |  |  | 87.25d |  |  | Sho | 120h |  |
| 31 | 8.1.6 | use hit time in tracking |  | 1w | 2013-11-04 | 2013-11-15 |  |  |  | 67.25d |  | start no earlier than 2013-08-12 | Sho | 40h |  |

| ID | WBS | Task | Type | Duration | Start | Finish | Predecessors | Complete | Remaining | Total slack | Free slack | Resources | Work | Actual work |
| --- | --- | --- | --- | --- | --- | --- | --- | --- | --- | --- | --- | --- | --- | --- |
| 32 | 8.2 | **Ecal recon improvements** |  | 39.5d | 2013-09-26 | 2013-11-20 |  |  |  | 64.75d |  |  | 160h |  |
| 33 | 8.2.1 | use sampling fraction in Ecal recon |  | 2w | 2013-09-26 | 2013-10-23 |  |  |  | 84.25d |  | INFN/Orsay | 80h |  |
| 34 | 8.2.2 | test clustering algorithm(s) |  | 2w | 2013-10-24 | 2013-11-20 |  |  |  | 64.25d |  | INFN/Orsay | 80h |  |
| 35 | 8.3 | **muon system recon** |  | 39.25d | 2013-07-01 | 2013-08-23 |  |  |  | 128d |  |  | 80h |  |
| 36 | 8.3.1 | muon system PID |  | 2w | 2013-07-01 | 2013-08-23 |  |  |  | 128d |  | Yuri/Keith | 80h |  |
| 37 | 8.4 | event filtering |  | 1mo | 2013-09-02 | 2013-10-25 |  |  |  | 82.25d |  | Matt | 160h |  |
| 38 | 9 | **monitoring** |  | 131.25d | 2013-07-01 | 2013-12-31 |  |  |  | 26d | 20.75d |  | 744h |  |
| 39 | 9.1 | "HPSED" (low-level monitoring) |  | 3w | 2013-09-02 | 2013-12-30 |  |  |  | 27.05d |  | Stacy | 120h |  |
| 40 | 9.2 | Wired event display |  | 2w | 2013-09-11 | 2013-11-05 |  |  |  | 66d |  | Jeremy | 80h |  |
| 41 | 9.3 | define interfaces for monitoring app components |  | 3d | 2013-07-01 | 2013-07-16 |  |  |  | 26d | 0d | Jeremy | 24h |  |
| 42 | 9.4 | Ecal monitoring |  | 2w | 2013-11-21 | 2013-12-18 | 41 |  |  | 35d |  | INFN/Orsay | 80h |  |
| 43 | 9.5 | Ecal low-level (DAQ) monitoring |  | 2w | 2013-12-02 | 2013-12-27 |  |  |  | 28d |  | Andrea | 80h |  |
| 44 | 9.6 | SVT monitoring |  | 1mo | 2013-07-16 | 2013-09-10 | 41 |  |  | 106.25d |  | Omar | 160h |  |
| 45 | 9.7 | muon monitoring |  | 3w | 2013-07-16 | 2013-08-06 | 41 |  |  | 131.75d |  | Kyle | 120h |  |
| 46 | 9.8 | shifter interface, monitoring app |  | 2w | 2013-11-06 | 2013-12-31 | 41 |  |  | 26d |  | Jeremy | 80h |  |
| 47 | 10 | **calibrations** |  | 71.5d | 2013-08-01 | 2013-11-08 |  |  |  | 82.75d |  |  | 320h |  |
| 48 | 10.1 | Ecal calibrations (cosmics, pions) |  | 1mo | 2013-08-01 | 2013-09-25 |  |  |  | 114.25d |  | INFN/Orsay | 160h |  |
| 49 | 10.2 | track-based SVT alignment |  | 1.98mo | 2013-09-16 | 2013-11-08 | 29 |  |  | 82.25d |  | Pelle | 160h |  |
| 50 | 11 | **infrastructure** |  | 59.25d | 2013-07-01 A | 2013-09-20 |  | 27% | 43.09d | 108d |  |  | 280h | 90h |
| 51 | 11.1 | set up sim production at Jlab | manual | 1.9w | 2013-07-15 A | 2013-07-26 A |  | 100% |  |  |  | Sho | 40h | 40h |
| 52 | 11.2 | set up recon production |  | 1w | 2013-08-12 | 2013-08-23 |  |  |  | 127.25d | 50d | Sho | 40h |  |
| 53 | 11.3 | set up DST transfer to SLAC |  | 1w | 2013-08-26 | 2013-09-20 |  |  |  | 108d |  | Homer | 40h |  |
| 54 | 11.4 | conditions system |  | 2w | 2013-07-17 A | 2013-09-10 |  | 50% | 1w | 6d | 0.75d | Jeremy | 80h | 40h |
| 55 | 11.5 | data catalog |  | 7.85w | 2013-07-01 A | 2013-08-23 |  | 11% | 7w | 98d | 63d | Homer | 80h | 10h |

| ID | WBS | Task | Type | Duration | Start | Finish | Predecessors | Total slack | Free slack | Resources | Work |
| --- | --- | --- | --- | --- | --- | --- | --- | --- | --- | --- | --- |
| 56 | 12 | **integration and commissioning** |  | 45.25d | 2014-01-01 | 2014-03-05 |  | 0d |  |  | 120h |
| 57 | 12.1 | integrate monitoring with ET system and conditions database |  | 1w | 2014-01-01 | 2014-01-28 | 54 | 6d | 0.75d | Jeremy | 40h |
| 58 | 12.2 | commissioning monitoring | manual | 3.85w | 2014-01-29 | 2014-02-25 | 57, 38 |  |  | Jeremy | 40h |
| 59 | 12.3 | commissioning recon production | manual | 2w | 2014-02-19 | 2014-03-05 | 24, 52, 53, 54, 55 |  |  | Sho | 40h |
